# Klystron Solenoid Power Supplies

Schedule from MS Project, 2009-06-15 to 2010-03-31.
SLAC National Accelerator Laboratory

## Calendars

- Calendar 1: Mon-Fri 08:00-12:00, 13:00-17:00; Sat-Sun off. Exceptions (off unless hours are given): 2009-12-21 to 2010-01-02 (SLAC Holiday).

## Resources

| Resource | Group |
| --- | --- |
| de Lira/Bellomo | PCD |
| Lipari/de Lira | PCD |
| Minister/Manh | PCD |
| Luchini | Controls |
| Luchini/Leahy | Controls |
| Hoffman | PCD |
| Technician | PCD |
| Ratkovsky | PCD |
| Sevilla | Facilities |

## Schedule

| ID | Task | Type | Duration | Start | Finish | Predecessors | Total slack | Free slack | Constraint | Resources | Work |
| --- | --- | --- | --- | --- | --- | --- | --- | --- | --- | --- | --- |
| 1 | Start | milestone | 0.2w | 2009-06-15 | 2009-06-15 |  | 0d |  |  |  |  |
| 2 | Manage project |  | 37w | 2009-06-16 | 2010-03-15 | 1 | 12d |  |  | de Lira/Bellomo [10%] | 156h |
| 3 | Permission for 2 DB racks |  | 2w | 2009-06-16 | 2009-06-29 | 1 | 100d | 0d |  | Ratkovsky [10%] | 8h |
| 4 | Request rack AC disconnect |  | 2w | 2009-06-30 | 2009-07-13 | 3 | 100d | 0d |  | Ratkovsky | 80h |
| 5 | Disconnect cables, move racks to B24 |  | 1w | 2009-07-14 | 2009-07-20 | 4 | 100d | 0d |  | Technician | 40h |
| 6 | Seismic bracing of racks |  | 4w | 2009-07-21 | 2009-08-17 | 5 | 100d | 5d |  | Minister/Manh [10%] | 16h |
| 7 | Draw EI diagrams |  | 8w | 2009-06-16 | 2009-08-10 | 1 | 0d |  |  | Minister/Manh [25%] | 80h |
| 8 | Draw rack front views |  | 4w | 2009-06-16 | 2009-07-13 | 1 | 90d | 20d |  | Minister/Manh [25%] | 40h |
| 9 | Purchase 19 power supplies |  | 15w | 2009-06-16 | 2009-09-28 | 1 | 95d | 0d |  | de Lira/Bellomo [10%] | 60h |
| 10 | Bench test 19 power supplies |  | 1w | 2009-09-29 | 2009-10-05 | 9 | 95d | 0d |  | Technician [75%] | 30h |
| 11 | Install PS into racks |  | 2w | 2009-10-06 | 2009-10-19 | 6, 8, 10 | 25d |  |  | Technician [50%] | 40h |
| 12 | Draw AC chassis |  | 4w | 2009-06-16 | 2009-07-13 | 1 | 78d | 0d |  | Minister/Manh [50%] | 80h |
| 13 | Purchase 4 AC chassis materials |  | 12w | 2009-07-14 | 2009-10-05 | 12 | 35d |  |  | Minister/Manh [25%] | 120h |
| 14 | Puchase 2 PLC |  | 12w | 2009-08-11 | 2009-11-02 | 7, 8 | 0d |  |  | Minister/Manh | 480h |
| 15 | Assemble 2 PLC |  | 2w | 2009-11-03 | 2009-11-16 | 14 | 0d |  |  | Technician [50%] | 40h |
| 16 | Bench test PLC |  | 1w | 2009-11-17 | 2009-11-23 | 15 | 0d |  |  | Technician | 40h |
| 17 | Purchase 19 LEM transductors |  | 8w | 2009-06-16 | 2009-08-10 | 1 | 145d |  |  | Minister/Manh [10%] | 32h |
| 18 | Bench test LEMs |  | 2w | 2009-08-11 | 2009-08-24 | 17 | 95d | 0d |  | Technician [15%] | 12h |
| 19 | Purchase 2 Digi-Ports |  | 8w | 2009-06-16 | 2009-08-10 | 1 | 135d | 0d |  | Luchini [10%] | 32h |
| 20 | Bench test 2 Digi-Ports |  | 2w | 2009-08-11 | 2009-08-24 | 19 | 65d |  |  | Luchini [25%] | 20h |
| 21 | Install other equip and wire racks |  | 6w | 2009-11-24 | 2010-01-18 | 6, 7, 8, 18, 11, 13, 16, 20 | 0d |  |  | Minister/Manh [10%]; Technician | 352h |
| 22 | EEIP Racks |  | 1w | 2010-01-19 | 2010-01-25 | 21 | 0d |  |  | Technician | 40h |
| 23 | Move and install racks in field |  | 1w | 2010-01-26 | 2010-02-01 | 22 | 0d |  |  |  |  |
| 24 | Controls programming |  | 6w | 2009-06-16 | 2009-07-27 | 1 | 155d |  |  | Luchini | 240h |
| 25 | Controls networking |  | 6w | 2009-06-16 | 2009-07-27 | 1 | 155d |  |  | Luchini/Leahy | 240h |
| 26 | Conduit work |  | 8w | 2009-08-03 | 2009-09-25 | 1 | 91d |  | start no earlier than 2009-08-02 | Technician [10%] | 32h |
| 27 | Purchase DC and EPICS cables |  | 10w | 2009-06-29 | 2009-09-04 | 1 | 86d | 0d | start no earlier than 2009-06-28 | Minister/Manh | 400h |
| 28 | Install DC and EPICS cables |  | 2w | 2009-09-07 | 2009-09-18 | 27 | 86d |  |  | Technician [25%] | 20h |
| 29 | Service Request to purchase 2 transformers and panelboards |  | 16w | 2009-06-16 | 2009-10-05 | 1 | 85d | 54d |  | Lipari/de Lira; Sevilla | 645.82h |
| 30 | Install transformers, panelboards and connect |  | 4w | 2010-01-04 | 2010-01-29 | 29, 26 | 1d |  | start no earlier than 2010-01-04 | Sevilla | 160h |
| 31 | System test Sector 19-20 |  | 2w | 2010-02-02 | 2010-02-15 | 23, 24, 25, 28, 30 | 0d |  |  | Lipari/de Lira [25%]; Technician [25%] | 40h |
| 32 | System test Sector 21-22 |  | 2w | 2010-02-16 | 2010-03-01 | 31 | 0d |  |  | Lipari/de Lira [25%]; Technician [25%] | 40h |
| 33 | System turn-over to LCLS |  | 0.2w? | 2010-03-02 | 2010-03-02 | 32 | 0d |  |  |  |  |
| 34 | As-built documentation |  | 4w | 2010-03-03 | 2010-03-30 | 33 | 0d |  |  | Lipari/de Lira; Minister/Manh | 320h |
| 35 | End | milestone | 1d | 2010-03-31 | 2010-03-31 | 34 | 0d |  |  |  |  |
